# Арабатка_2

Schedule from MS Project, 2013-04-01 to 2030-08-15.
Grizli777

## Calendars

- Стандартный: Mon-Fri 09:00-13:00, 14:00-18:00; Sat-Sun off.

## Schedule

| ID | WBS | Task | Type | Duration | Start | Finish | Predecessors | Total slack | Free slack |
| --- | --- | --- | --- | --- | --- | --- | --- | --- | --- |
| 1 | 1 | **Проект створення IntermedicalEcoCity** |  | 4534d | 2013-04-01 | 2030-08-15 |  | 0d |  |
| 2 | 1.1 | **Підготовча фаза** |  | 177d | 2013-04-01 | 2013-12-03 |  | 0d |  |
| 3 | 1.1.1 | **Передінвестиційні дослідження** |  | 115d | 2013-04-01 | 2013-09-06 |  | 0d |  |
| 4 | 1.1.1.1 | **Дослідження умов реалізації проекту** |  | 35d | 2013-04-01 | 2013-05-17 |  | 0d |  |
| 5 | 1.1.1.1.1 | Експертиза представленої проектної пропозиції |  | 12d | 2013-04-01 | 2013-04-16 |  | 0d |  |
| 6 | 1.1.1.1.2 | Експрес-аналіз соціально-економічних та екологічних умов реалізації проекту та технічних рішень |  | 9d | 2013-04-17 | 2013-04-29 | 5 | 1d |  |
| 7 | 1.1.1.1.3 | Створення та аналіз структурно-логічної матриці проекту |  | 10d | 2013-04-17 | 2013-04-30 | 5 | 0d |  |
| 8 | 1.1.1.1.4 | Аналіз можливості та доцільності реалізації проекту |  | 8d | 2013-05-01 | 2013-05-10 | 7, 6 | 0d |  |
| 9 | 1.1.1.1.5 | Прийняття рішення про подальшу роботу за проектом | milestone | 5d | 2013-05-13 | 2013-05-17 | 8 | 0d |  |
| 10 | 1.1.1.2 | **Розроблення попереднього техніко-економічного обгрунтування проекту** |  | 54d | 2013-05-20 | 2013-08-01 | 9, 4 | 0d |  |
| 11 | 1.1.1.2.1 | Галузеве, технологічне та ринкове обґрунтування необхідності реалізації проекту |  | 5d | 2013-05-20 | 2013-05-24 | 9 | 48d |  |
| 12 | 1.1.1.2.2 | Дослідження інвестиційних можливостей |  | 3d | 2013-05-20 | 2013-05-22 | 9 | 50d |  |
| 13 | 1.1.1.2.3 | Проведення попередніх маркетингових досліджень |  | 15d | 2013-05-20 | 2013-06-07 | 9 | 5d |  |
| 14 | 1.1.1.2.4 | Проведення попередніх проектно-конструкторських розрахунків, проектно-будівельне планування |  | 20d | 2013-05-20 | 2013-06-14 | 9 | 0d |  |
| 15 | 1.1.1.2.5 | Визначення наявності необхідних ресурсів |  | 15d | 2013-06-17 | 2013-07-05 | 14 | 18d |  |
| 16 | 1.1.1.2.6 | Фінансовий аналіз проекту, створення альтернативних моделей фінансування |  | 12d | 2013-06-17 | 2013-07-02 | 13, 14 | 0d |  |
| 17 | 1.1.1.2.7 | Вибір оптимальної моделі фінансування |  | 5d | 2013-07-03 | 2013-07-09 | 16 | 16d |  |
| 18 | 1.1.1.2.8 | Визначення форми участі держави та створення моделі надання державної підтримки |  | 4d | 2013-07-03 | 2013-07-08 | 16 | 0d |  |
| 19 | 1.1.1.2.9 | Обгрунтування організаційно-правової форми реалізації проекту |  | 7d | 2013-07-09 | 2013-07-17 | 18 | 0d |  |
| 20 | 1.1.1.2.10 | Підготовка до отримання дозвильної документації, в тому числі для забезпечення земельними ділянками |  | 10d | 2013-07-18 | 2013-07-31 | 18, 19 | 0d |  |
| 21 | 1.1.1.2.11 | Розроблення плану виробничої діяльності |  | 14d | 2013-07-03 | 2013-07-22 | 16 | 2d | 0d |
| 22 | 1.1.1.2.12 | Прогнозна оцінка ефективності проекту |  | 5d | 2013-07-23 | 2013-07-29 | 21 | 2d |  |
| 23 | 1.1.1.2.13 | Попереднє ТЕО створено | milestone | 1d | 2013-08-01 | 2013-08-01 | 15, 20, 22, 11, 12, 17 | 0d |  |
| 24 | 1.1.1.3 | **Розроблення техніко-економічного обгрунтування** |  | 26d | 2013-08-02 | 2013-09-06 | 10 | 0d |  |
| 25 | 1.1.1.3.1 | Розробка сценаріїв реалізації проекту |  | 5d | 2013-08-02 | 2013-08-08 | 23 | 0d |  |
| 26 | 1.1.1.3.2 | Оцінка ризиків проекту |  | 5d | 2013-08-02 | 2013-08-08 | 23 | 20d |  |
| 27 | 1.1.1.3.3 | Обгрунтування моделі діяльності та складу уповноваженного органу з управління проектом |  | 5d | 2013-08-09 | 2013-08-15 | 25 | 15d |  |
| 28 | 1.1.1.3.4 | Розробка пакету інвестиційних документів |  | 14d | 2013-08-02 | 2013-08-21 | 23 | 11d |  |
| 29 | 1.1.1.3.5 | Розробка бізнес-плану |  | 14d | 2013-08-02 | 2013-08-21 | 23 | 11d |  |
| 30 | 1.1.1.3.6 | Розробка проектно-кошторисної документації |  | 20d | 2013-08-09 | 2013-09-05 | 25 | 0d |  |
| 31 | 1.1.1.3.7 | ТЕО розроблено | milestone | 1d | 2013-09-06 | 2013-09-06 | 27, 30, 26, 28, 29 | 0d |  |

| ID | WBS | Task | Type | Duration | Start | Finish | Predecessors | Total slack | Free slack |
| --- | --- | --- | --- | --- | --- | --- | --- | --- | --- |
| 32 | 1.1.2 | **Розробка системи менеджменту проекту** |  | 61d | 2013-09-09 | 2013-12-02 | 24 | 1d |  |
| 33 | 1.1.2.1 | Розроблення технології менеджменту з урахуванням очікуваних змін |  | 17d | 2013-09-09 | 2013-10-01 | 31 | 45d | 44d |
| 34 | 1.1.2.2 | Розроблення системи прийняття раціональних управлінських рішень |  | 15d | 2013-11-12 | 2013-12-02 | 41 | 1d | 0d |
| 35 | 1.1.2.3 | Розроблення системи комунікацій та управління інтеграцією в проекті |  | 14d | 2013-09-09 | 2013-09-26 | 31 | 35d | 0d |
| 36 | 1.1.2.4 | Розроблення системи управління змістом в проекті |  | 14d | 2013-09-09 | 2013-09-26 | 31 | 1d | 0d |
| 37 | 1.1.2.5 | Розроблення системи управління часом у проекті |  | 14d | 2013-09-09 | 2013-09-26 | 31 | 48d | 47d |
| 38 | 1.1.2.6 | Розроблення системи управління вартістю у проекті |  | 10d | 2013-09-09 | 2013-09-20 | 31 | 38d | 0d |
| 39 | 1.1.2.7 | Розроблення системи управління якістю у проекті |  | 14d | 2013-09-27 | 2013-10-16 | 36 | 1d | 0d |
| 40 | 1.1.2.8 | Розроблення системи управління ресурсами у проекті |  | 13d | 2013-09-27 | 2013-10-15 | 35 | 35d | 34d |
| 41 | 1.1.2.9 | Аналіз ризиків та розробка системи управління ризиками проекту |  | 18d | 2013-10-17 | 2013-11-11 | 39 | 1d | 0d |
| 42 | 1.1.2.10 | Розроблення системи управління закупівлями у проекті |  | 14d | 2013-09-23 | 2013-10-10 | 38 | 38d | 37d |
| 43 | 1.1.2.11 | Систему менеджменту проекту створено | milestone | 0d | 2013-12-02 | 2013-12-02 | 33, 34, 37, 40, 41, 42 | 1d |  |
| 44 | 1.1.3 | **Розробка системи маркетингу проекту** |  | 62d | 2013-09-09 | 2013-12-03 | 24 | 0d |  |
| 45 | 1.1.3.1 | Розробка концепції маркетингу |  | 7d | 2013-09-09 | 2013-09-17 | 31 | 0d |  |
| 46 | 1.1.3.2 | Розробка та затвердження програми маркетингу |  | 25d | 2013-09-18 | 2013-10-22 | 45 | 0d |  |
| 47 | 1.1.3.3 | Розробка плану роботи з інвесторами |  | 5d | 2013-10-23 | 2013-10-29 | 46 | 25d |  |
| 48 | 1.1.3.4 | Розробка плану маркетингу |  | 30d | 2013-10-23 | 2013-12-03 | 46 | 0d |  |
| 49 | 1.1.3.5 | Систему маркетингу проекту розроблено | milestone | 0d | 2013-12-03 | 2013-12-03 | 48, 47 | 0d |  |
| 50 | 1.1.4 | Підготовчу фазу завершено | milestone | 0d | 2013-12-03 | 2013-12-03 | 44, 32 | 0d |  |
| 51 | 1.2 | **Інвестиційна фаза** |  | 4444d | 2013-08-05 | 2030-08-15 |  | 0d |  |
| 52 | 1.2.1 | **Робота щодо забезпечення фінансування проекту** |  | 120d | 2013-12-04 | 2014-05-20 | 50, 2 | 0d |  |
| 53 | 1.2.1.1 | Пошук інвесторів та проведення переговорів |  | 90d | 2013-12-04 | 2014-04-08 | 50 | 0d |  |
| 54 | 1.2.1.2 | Укладання угод про співпрацю |  | 30d | 2014-04-09 | 2014-05-20 | 53 | 0d |  |
| 55 | 1.2.2 | **Реалізація програми маркетингу** |  | 261d | 2013-08-05 | 2014-08-04 |  | 4183d |  |
| 56 | 1.2.2.1 | **Проведення періодичних маркетингових досліджень** |  | 42d | 2013-12-04 | 2014-01-30 | 2 | 4280d | 0d |
| 57 | 1.2.2.1.1 | Проведення маркетингового дослідження |  | 30d | 2013-12-04 | 2014-01-14 | 50 | 4280d | 0d |
| 58 | 1.2.2.1.2 | Обробка результатів маркетингового дослідження |  | 5d | 2014-01-15 | 2014-01-21 | 57 | 4280d | 0d |
| 59 | 1.2.2.1.3 | Коректування плану маркетингу |  | 5d | 2014-01-22 | 2014-01-28 | 58 | 4282d |  |
| 60 | 1.2.2.1.4 | Внесення змін у проектну документацію |  | 7d | 2014-01-22 | 2014-01-30 | 58 | 4280d | 0d |

| ID | WBS | Task | Type | Duration | Start | Finish | Predecessors | Total slack | Free slack | Constraint |
| --- | --- | --- | --- | --- | --- | --- | --- | --- | --- | --- |
| 61 | 1.2.2.2 | **Реалізація маркетингових заходів** |  | 35d | 2014-01-31 | 2014-03-20 | 56 | 4280d |  |  |
| 62 | 1.2.2.2.1 | Управління продуктом проекту |  | 7d | 2014-01-31 | 2014-02-10 | 60 | 4280d | 0d |  |
| 63 | 1.2.2.2.2 | Управління ціною передбачуваних послуг |  | 14d | 2014-02-11 | 2014-02-28 | 62 | 4280d | 0d |  |
| 64 | 1.2.2.2.3 | Управління збутом |  | 14d | 2014-03-03 | 2014-03-20 | 63 | 4280d |  |  |
| 65 | 1.2.2.2.4 | Управління цільовою аудиторією проекту |  | 14d | 2014-03-03 | 2014-03-20 | 63 | 4280d |  |  |
| 66 | 1.2.2.2.5 | Управління зовнішнім оточенням проекту |  | 14d | 2014-03-03 | 2014-03-20 | 63 | 4280d |  |  |
| 67 | 1.2.2.3 | Реалізація програми маркетингу 1 |  | 1d | 2013-08-05 | 2013-08-05 |  | 4443d |  | start no earlier than 2013-08-03 |
| 68 | 1.2.2.4 | Реалізація програми маркетингу 2 |  | 1d | 2014-08-04 | 2014-08-04 |  | 4183d |  | start no earlier than 2014-08-03 |
| 69 | 1.2.3 | **Створення обєктів оздоровчої зони (І черга)** |  | 1437d | 2014-05-21 | 2019-11-21 | 54 | 0d |  |  |
| 70 | 1.2.3.1 | Забезпечення земельною ділянкою |  | 30d | 2014-05-21 | 2014-07-01 | 54 | 0d |  |  |
| 71 | 1.2.3.2 | Будівельно-монтажні роботи |  | 530d | 2014-07-02 | 2016-07-12 | 70 | 0d |  |  |
| 72 | 1.2.3.3 | Встановлення медичного обладнання, діагностичного і лабораторного устаткування, меблі, закупка інвентарю |  | 60d | 2016-07-13 | 2016-10-04 | 71 | 0d |  |  |
| 73 | 1.2.3.4 | Пуско-налагоджувальні роботи |  | 35d | 2016-10-05 | 2019-11-14 | 72 | 0d |  | start no earlier than 2013-10-07 |
| 74 | 1.2.3.5 | Запуск І черги обєктів оздоровчої зони | milestone | 5d | 2019-11-15 | 2019-11-21 | 73 | 0d |  |  |
| 75 | 1.2.4 | **Створення обєктів оздоровчої зони (ІІ черга)** |  | 801d | 2019-11-22 | 2022-12-16 | 69 | 1999d |  |  |
| 76 | 1.2.4.1 | Забезпечення земельною ділянкою |  | 60d | 2019-11-22 | 2020-02-13 | 73 | 1999d | 0d |  |
| 77 | 1.2.4.2 | Будівельно-монтажні роботи |  | 640d | 2020-02-14 | 2022-07-28 | 76 | 1999d | 0d |  |
| 78 | 1.2.4.3 | Встановлення медичного обладнання, діагностичного та лабораторного устаткування, меблі, закупка інвентарю |  | 56d | 2022-07-29 | 2022-10-14 | 77 | 1999d | 0d |  |
| 79 | 1.2.4.4 | Пуско-налагоджувальні роботи |  | 40d | 2022-10-17 | 2022-12-09 | 78 | 1999d | 0d |  |
| 80 | 1.2.4.5 | Запуск ІІ черги обєктів оздоровчої зони | milestone | 5d | 2022-12-12 | 2022-12-16 | 79 | 1999d |  |  |
| 81 | 1.2.5 | **Підготовка площадки для реалізації локальних інвестиційних проектів (ІІІ черга)** |  | 840d | 2019-11-22 | 2023-02-09 | 69 | 0d |  |  |
| 82 | 1.2.5.1 | Утворення території під капітальну забудову |  | 430d | 2019-11-22 | 2021-07-15 | 73 | 0d |  |  |
| 83 | 1.2.5.2 | Створення системи водопостачання |  | 210d | 2021-07-16 | 2022-05-05 | 82 | 200d | 150d |  |
| 84 | 1.2.5.3 | Створення каналізаційної мережі |  | 180d | 2021-07-16 | 2022-03-24 | 82 | 230d | 180d |  |
| 85 | 1.2.5.4 | Підготовка транспортної мережі |  | 410d | 2021-07-16 | 2023-02-09 | 82 | 0d |  |  |
| 86 | 1.2.5.5 | Спорудження КСЕСТ |  | 360d | 2021-07-16 | 2022-12-01 | 82 | 50d | 0d |  |
| 87 | 1.2.5.6 | Площадку ІІІ черги підготовлено | milestone | 0d | 2022-12-01 | 2022-12-01 | 83, 84, 86 | 50d | 0d |  |

| ID | WBS | Task | Type | Duration | Start | Finish | Predecessors | Total slack | Free slack |
| --- | --- | --- | --- | --- | --- | --- | --- | --- | --- |
| 88 | 1.2.6 | **Реалізація локальних інвестиційних проектів (ІІІ черга)** |  | 1280d | 2023-02-10 | 2028-01-06 | 81 | 0d |  |
| 89 | 1.2.6.1 | Санаторії для батьків з дітьми та дитячі санаторії |  | 770d | 2023-02-10 | 2026-01-22 | 87 | 140d | 0d |
| 90 | 1.2.6.2 | Розважальний центр |  | 210d | 2026-01-23 | 2026-11-12 | 89, 91 | 180d | 0d |
| 91 | 1.2.6.3 | Курортні готелі |  | 560d | 2023-02-10 | 2025-04-03 | 87 | 0d |  |
| 92 | 1.2.6.4 | Пансіонати |  | 720d | 2023-02-10 | 2025-11-13 | 87 | 440d | 260d |
| 93 | 1.2.6.5 | Міні-пансіонати |  | 280d | 2023-02-10 | 2024-03-07 | 87 | 845d | 0d |
| 94 | 1.2.6.6 | Молодіжний табір |  | 155d | 2024-03-08 | 2024-10-10 | 93 | 845d |  |
| 95 | 1.2.6.7 | Етнокомплекси |  | 370d | 2026-01-23 | 2027-06-24 | 89 | 140d |  |
| 96 | 1.2.6.8 | Басейни |  | 120d | 2026-11-13 | 2027-04-29 | 90, 92, 93 | 180d |  |
| 97 | 1.2.6.9 | Житлова забудова |  | 720d | 2025-04-04 | 2028-01-06 | 91 | 0d |  |
| 98 | 1.2.6.10 | Коледж |  | 212d | 2025-04-04 | 2026-01-26 | 91 | 508d |  |
| 99 | 1.2.6.11 | Обєкти туристичної інфраструктури підготовлено | milestone | 0d | 2028-01-06 | 2028-01-06 | 94, 95, 96, 97, 98 | 0d |  |
| 100 | 1.2.7 | **Підготовка площадки для реалізації локальних інвестиційних проектів (ІV черга)** |  | 750d | 2022-12-02 | 2025-10-16 | 87 | 580d |  |
| 101 | 1.2.7.1 | Підготовка території, гідротехнічні заходи |  | 330d | 2022-12-02 | 2024-03-07 | 87 | 580d | 0d |
| 102 | 1.2.7.2 | Створення системи водопостачання |  | 130d | 2024-03-08 | 2024-09-05 | 101 | 870d | 290d |
| 103 | 1.2.7.3 | Створення каналізаційної мережі |  | 180d | 2024-03-08 | 2024-11-14 | 101 | 580d | 0d |
| 104 | 1.2.7.4 | Спорудження КСЕСТ |  | 240d | 2024-11-15 | 2025-10-16 | 103 | 580d | 0d |
| 105 | 1.2.7.5 | Площадку ІІІ черги підготовлено | milestone | 0d | 2025-10-16 | 2025-10-16 | 102, 104 | 580d |  |
| 106 | 1.2.8 | **Реалізація локальних інвестиційних проектів (ІІІ черга)** |  | 680d | 2028-01-07 | 2030-08-15 | 88, 100, 105, 99 | 0d |  |
| 107 | 1.2.8.1 | Аквапарк |  | 330d | 2028-01-07 | 2029-04-12 | 99, 105 | 0d |  |
| 108 | 1.2.8.2 | Універсальний розважальний центр |  | 270d | 2028-01-07 | 2029-01-18 | 99, 105 | 230d | 0d |
| 109 | 1.2.8.3 | Спортивний центр |  | 270d | 2029-04-13 | 2030-04-25 | 107 | 80d |  |
| 110 | 1.2.8.4 | Торгово-виставковий центр |  | 350d | 2029-04-13 | 2030-08-15 | 107 | 0d |  |
| 111 | 1.2.8.5 | Тематичні парки |  | 180d | 2029-01-19 | 2029-09-27 | 108 | 230d |  |
| 112 | 1.2.8.6 | Обєкти парково-громадської зони підготовлено | milestone | 0d | 2030-08-15 | 2030-08-15 | 109, 110, 111 | 0d |  |
| 113 | 1.2.9 | Інвестиційну фазу завершено | milestone | 0d | 2030-08-15 | 2030-08-15 | 112, 106 | 0d |  |
