# Арабатка_1-2007

Schedule from MS Project, 2013-07-15 to 2026-04-09, costs in р..
SPecialiST RePack

## Calendars

- Стандартный: Mon-Fri 09:00-13:00, 14:00-18:00; Sat-Sun off.

## Resources

| Resource | Unit | Cost per use |
| --- | --- | --- |
| Комерційні інвестиції | млн. грн. |  |
| Бюджетні капітальні інвестиції | млн. грн. | 3121.62 |
| Бюджетні інвестиції підготовчої фази | млн. грн. | 35 |
| Витрати на просування проекту |  | 35 |

## Schedule

| ID | WBS | Task | Type | Duration | Start | Finish | Predecessors | Total slack | Free slack | Constraint | Cost |
| --- | --- | --- | --- | --- | --- | --- | --- | --- | --- | --- | --- |
| 1 | 1 | **Проект створення IntermedicalEcoCity** |  | 3324d | 2013-07-15 | 2026-04-09 |  | -472d | 0d |  | 7,796.45 |
| 2 | 1.1 | **Підготовча фаза** |  | 474d | 2013-07-15 | 2015-05-08 |  | -472d | 0d |  | 4.48 |
| 3 | 1.1.1 | **Створення документального супроводу проекту** |  | 290d | 2013-07-15 | 2014-08-25 |  | -472d | 0d |  | 1.77 |
| 4 | 1.1.1.1 | Розроблення Стратегічного плану розвитку території |  | 35d | 2013-07-15 | 2013-08-30 |  | -472d | 0d | start no earlier than 2013-07-15 | 0.19 |
| 5 | 1.1.1.2 | Розроблення Генерального плану розвитку території |  | 60d | 2013-09-02 | 2013-11-22 | 4 | -472d | 0d | start no earlier than 2013-09-02 | 0.33 |
| 6 | 1.1.1.3 | Затвердження Стратегічного та Генерального планів розвитку території |  | 30d | 2013-11-25 | 2014-01-03 | 5 | -472d | 0d | start no earlier than 2013-11-25 | 0.17 |
| 7 | 1.1.1.4 | Розроблення та затвердження проектно-архітектурної та проектно-кошторисної документації |  | 90d | 2014-01-06 | 2014-05-09 | 6 | -472d | 0d | start no earlier than 2014-01-06 | 0.5 |
| 8 | 1.1.1.5 | Налагодження горизонтального кореспондування між галузевими програмами й заходами щодо реалізації проекту |  | 30d | 2014-01-06 | 2014-02-14 | 6 | -337d | 0d |  | 0.17 |
| 9 | 1.1.1.6 | Розробка плану реалізації проекту |  | 60d | 2014-05-12 | 2014-08-01 | 7 | -472d | 0d | start no earlier than 2014-05-12 | 0.33 |
| 10 | 1.1.1.7 | Затвердження плану реалізації проекту |  | 15d | 2014-08-04 | 2014-08-22 | 9 | -472d | 0d | start no earlier than 2014-08-04 | 0.08 |
| 11 | 1.1.1.8 | Документальний супровід проекту створено | milestone | 0d | 2014-08-25 | 2014-08-25 | 7, 8, 10 | -472d | 0d | start no earlier than 2014-08-25 |  |
| 12 | 1.1.2 | **Підготовка до запуску проекту** |  | 184d | 2014-08-25 | 2015-05-08 | 3, 11 | -472d | 0d |  | 2.71 |
| 13 | 1.1.2.1 | **Створення керуючої компанії** |  | 120d | 2014-08-25 | 2015-02-09 | 3, 11 | -472d | 0d |  | 1.15 |
| 14 | 1.1.2.1.1 | Розробка та затвердження статуту компанії |  | 15d | 2014-08-25 | 2014-09-12 | 3, 11 | -472d | 0d | start no earlier than 2014-08-25 | 0.08 |
| 15 | 1.1.2.1.2 | Розробка та затвердження організаційної структури компанії |  | 15d | 2014-09-15 | 2014-10-03 | 14 | -472d | 0d | start no earlier than 2014-09-15 | 0.08 |
| 16 | 1.1.2.1.3 | Розробка та затвердження положень про підрозділи та відділи компанії |  | 30d | 2014-10-06 | 2014-11-14 | 15 | -472d | 0d | start no earlier than 2014-10-06 | 0.17 |
| 17 | 1.1.2.1.4 | Розробка та затвердження штатного розкладу компанії |  | 15d | 2014-11-17 | 2014-12-05 | 16 | -472d | 0d | start no earlier than 2014-11-17 | 0.08 |
| 18 | 1.1.2.1.5 | Розробка та затвердження інструкцій для працівників компанії |  | 10d | 2014-12-08 | 2014-12-19 | 17 | -472d | 0d | start no earlier than 2014-12-08 | 0.55 |
| 19 | 1.1.2.1.6 | Проведенння конкурсу на заміщення вільних посад |  | 30d | 2014-12-22 | 2015-01-30 | 18 | -472d | 0d | start no earlier than 2014-12-22 | 0.17 |
| 20 | 1.1.2.1.7 | Призначення на посаду |  | 5d | 2015-02-02 | 2015-02-06 | 19 | -472d | 0d | start no earlier than 2015-02-02 | 0.02 |
| 21 | 1.1.2.1.8 | Керуючу компанію створено | milestone | 0d | 2015-02-09 | 2015-02-09 | 20 | -472d | 0d | start no earlier than 2015-02-09 |  |
| 22 | 1.1.2.2 | **Розробка системи менеджменту проекту** |  | 64d | 2015-02-09 | 2015-05-08 | 13, 21 | -457d | 0d |  | 1.22 |
| 23 | 1.1.2.2.1 | Розроблення технології менеджменту з урахуванням очікуваних змін | manual | 17d | 2015-02-09 | 2015-03-03 | 13, 21 |  |  | start no earlier than 2015-02-09 | 0.08 |
| 24 | 1.1.2.2.2 | Розроблення системи прийняття раціональних управлінських рішень |  | 15d | 2015-04-17 | 2015-05-07 | 31 | -474d | 0d | start no earlier than 2015-04-17 | 0.08 |
| 25 | 1.1.2.2.3 | Розроблення системи комунікацій та управління інтеграцією в проекті | manual | 14d | 2015-03-04 | 2015-03-23 | 23 |  |  | start no earlier than 2015-03-04 | 0.07 |
| 26 | 1.1.2.2.4 | Розроблення системи управління змістом в проекті |  | 14d | 2015-03-04 | 2015-03-23 | 23 | -465d | 0d | start no earlier than 2015-03-04 | 0.07 |
| 27 | 1.1.2.2.5 | Розроблення системи управління часом у проекті |  | 14d | 2015-03-04 | 2015-03-23 | 23 | -455d | 0d | start no earlier than 2015-03-04 | 0.07 |
| 28 | 1.1.2.2.6 | Розроблення системи управління вартістю у проекті |  | 10d | 2015-03-24 | 2015-04-06 | 26 | -465d | 0d | start no earlier than 2015-03-24 | 0.55 |
| 29 | 1.1.2.2.7 | Розроблення системи управління якістю у проекті |  | 14d | 2015-04-07 | 2015-04-24 | 25, 26, 27, 28 | -465d | 0d | start no earlier than 2015-04-07 | 0.07 |
| 30 | 1.1.2.2.8 | Розроблення системи управління ресурсами у проекті |  | 13d | 2015-03-04 | 2015-03-20 | 23 | -473d | 0d | start no earlier than 2015-03-04 | 0.07 |
| 31 | 1.1.2.2.9 | Аналіз ризиків та розробка системи управління ризиками проекту |  | 18d | 2015-03-24 | 2015-04-16 | 30, 32 | -474d | 0d | start no earlier than 2015-03-24 | 0.09 |
| 32 | 1.1.2.2.10 | Розроблення системи управління закупівлями у проекті |  | 14d | 2015-03-04 | 2015-03-23 | 23 | -474d | 0d | start no earlier than 2015-03-04 | 0.07 |
| 33 | 1.1.2.2.11 | Систему менеджменту проекту створено | milestone | 0d | 2015-05-08 | 2015-05-08 | 24, 29, 31 | -474d | 0d | start no earlier than 2015-05-08 |  |

Notes:
- 2: Витрати підготовчої фази
- 3: Витрати підготовчої фази
- 4: Витрати підготовчої фази
- 5: Витрати підготовчої фази
- 6: Витрати підготовчої фази
- 7: Витрати підготовчої фази
- 8: Витрати підготовчої фази
- 9: Витрати підготовчої фази
- 10: Витрати підготовчої фази
- 12: Витрати на підготовку до запуску проекту
- 13: Витрати на підготовку до запуску проекту
- 14: Витрати на підготовку до запуску проекту
- 15: Витрати на підготовку до запуску проекту
- 16: Витрати на підготовку до запуску проекту
- 17: Витрати на підготовку до запуску проекту
- 18: Витрати на підготовку до запуску проекту
- 19: Витрати на підготовку до запуску проекту
- 20: Витрати на підготовку до запуску проекту
- 22: Витрати на підготовку до запуску проекту
- 23: Витрати на підготовку до запуску проекту
- 24: Витрати на підготовку до запуску проекту
- 25: Витрати на підготовку до запуску проекту
- 26: Витрати на підготовку до запуску проекту
- 27: Витрати на підготовку до запуску проекту
- 28: Витрати на підготовку до запуску проекту
- 29: Витрати на підготовку до запуску проекту
- 30: Витрати на підготовку до запуску проекту
- 31: Витрати на підготовку до запуску проекту
- 32: Витрати на підготовку до запуску проекту

| ID | WBS | Task | Type | Duration | Start | Finish | Predecessors | Total slack | Free slack | Constraint | Cost |
| --- | --- | --- | --- | --- | --- | --- | --- | --- | --- | --- | --- |
| 34 | 1.1.2.3 | **Розробка системи маркетингу проекту** |  | 62d | 2015-02-09 | 2015-05-05 | 13, 21 | -472d | 0d |  | 0.34 |
| 35 | 1.1.2.3.1 | Розробка концепції маркетингу |  | 7d | 2015-02-09 | 2015-02-17 | 13, 21 | -472d | 0d |  | 0.03 |
| 36 | 1.1.2.3.2 | Розробка та затвердження програми маркетингу |  | 25d | 2015-02-18 | 2015-03-24 | 35 | -472d | 0d |  | 0.14 |
| 37 | 1.1.2.3.3 | Розробка плану маркетингу |  | 30d | 2015-03-25 | 2015-05-05 | 36 | -472d | 0d |  | 0.17 |
| 38 | 1.1.2.3.4 | Систему маркетингу проекту розроблено | milestone | 0d | 2015-05-05 | 2015-05-05 | 37 | -472d | 0d |  |  |
| 39 | 1.2 | **Реалізація програми маркетингу** |  | 3132d | 2013-07-15 | 2025-07-15 | 33, 38 | 0d |  |  | 32.45 |
| 41 | 1.2.1 | **1** |  | 1d | 2013-07-15 | 2013-07-15 |  | 3323d |  | start no earlier than 2013-07-15 | 0.55 |
| 42 | 1.2.1.1 | 2 |  | 1d | 2014-07-15 | 2014-07-15 |  | 3062d |  | start no earlier than 2014-07-15 | 0.55 |
| 43 | 1.2.1.2 | 3 |  | 1d | 2015-07-15 | 2015-07-15 |  | 2801d |  | start no earlier than 2015-07-15 | 0.55 |
| 44 | 1.2.1.3 | 4 |  | 1d | 2016-07-15 | 2016-07-15 |  | 2539d |  | start no earlier than 2016-07-15 | 0.55 |
| 45 | 1.2.1.4 | 5 |  | 1d | 2019-07-15 | 2019-07-15 |  | 1758d |  | start no earlier than 2019-07-15 | 0.55 |
| 46 | 1.2.1.5 | 6 |  | 1d | 2020-07-15 | 2020-07-15 |  | 1496d |  | start no earlier than 2020-07-15 | 0.55 |
| 47 | 1.2.1.6 | 7 |  | 1d | 2021-07-15 | 2021-07-15 |  | 1235d |  | start no earlier than 2021-07-15 | 0.55 |
| 48 | 1.2.1.7 | 8 |  | 1d | 2022-07-15 | 2022-07-15 |  | 974d |  | start no earlier than 2022-07-15 | 0.55 |
| 49 | 1.2.1.8 | 9 |  | 1d | 2024-07-15 | 2024-07-15 |  | 453d |  | start no earlier than 2024-07-15 | 0.55 |
| 50 | 1.2.1.9 | 10 |  | 1d | 2025-07-15 | 2025-07-15 |  | 192d |  | start no earlier than 2025-07-15 | 0.55 |
| 51 | 1.2.2 | **Проведення периодичних маркетингових досліджень** |  | 2658d | 2015-05-08 | 2025-07-15 | 33, 38 |  |  |  | 24.55 |
| 52 | 1.2.2.1 | Проведення маркетингового дослідження | manual | 30d | 2015-05-08 | 2015-06-18 | 33, 38 |  |  |  | 0.3 |
| 53 | 1.2.2.2 | Обробка результатів маркетингового дослідження |  | 15d | 2015-06-19 | 2015-07-09 | 52 | 2598d | 0d |  | 0.05 |
| 54 | 1.2.2.3 | Коректування плану маркетингу |  | 15d | 2015-07-10 | 2015-07-30 | 53 | 2598d |  |  | 0.1 |
| 55 | 1.2.2.4 | **Внесення змін у проектну документацію** |  | 15d | 2015-07-10 | 2015-07-30 | 53 | 2598d |  |  | 0.1 |
| 57 | 1.2.2.4.1 | 1 |  | 1d | 2015-05-08 | 2015-05-08 |  | 2657d |  | start no earlier than 2013-07-15 | 2.4 |
| 58 | 1.2.2.4.2 | 2 |  | 1d | 2015-05-08 | 2015-05-08 |  | 2657d |  | start no earlier than 2014-07-15 | 2.4 |
| 59 | 1.2.2.4.3 | 3 |  | 1d | 2015-07-15 | 2015-07-15 |  | 2609d |  | start no earlier than 2015-07-15 | 2.4 |
| 60 | 1.2.2.4.4 | 4 |  | 1d | 2016-07-15 | 2016-07-15 |  | 2347d |  | start no earlier than 2016-07-15 | 2.4 |
| 61 | 1.2.2.4.5 | 5 |  | 1d | 2019-07-15 | 2019-07-15 |  | 1566d |  | start no earlier than 2019-07-15 | 2.4 |
| 62 | 1.2.2.4.6 | 6 |  | 1d | 2020-07-15 | 2020-07-15 |  | 1304d |  | start no earlier than 2020-07-15 | 2.4 |
| 63 | 1.2.2.4.7 | 7 |  | 1d | 2021-07-15 | 2021-07-15 |  | 1043d |  | start no earlier than 2021-07-15 | 2.4 |
| 64 | 1.2.2.4.8 | 8 |  | 1d | 2022-07-15 | 2022-07-15 |  | 782d |  | start no earlier than 2022-07-15 | 2.4 |
| 65 | 1.2.2.4.9 | 9 |  | 1d | 2024-07-15 | 2024-07-15 |  | 261d |  | start no earlier than 2024-07-15 | 2.4 |
| 66 | 1.2.2.4.10 | 10 |  | 1d | 2025-07-15 | 2025-07-15 |  | 0d |  | start no earlier than 2025-07-15 | 2.4 |

Notes:
- 34: Витрати на підготовку до запуску проекту
- 35: Витрати на підготовку до запуску проекту
- 36: Витрати на підготовку до запуску проекту
- 37: Витрати на підготовку до запуску проекту
- 39: Витрати на просування проекту
- 51: Витрати на просування проекту
- 52: Витрати на просування проекту
- 53: Витрати на просування проекту
- 54: Витрати на просування проекту
- 55: Витрати на просування проекту

| ID | WBS | Task | Type | Duration | Start | Finish | Predecessors | Total slack | Free slack | Constraint | Cost |
| --- | --- | --- | --- | --- | --- | --- | --- | --- | --- | --- | --- |
| 67 | 1.2.3 | **Реалізація маркетингових заходів** |  | 45d | 2015-05-08 | 2015-07-09 | 33, 38 | 2805d |  |  | 2.4 |
| 68 | 1.2.3.1 | Управління продуктом проекту |  | 15d | 2015-05-08 | 2015-05-28 | 33, 38 | 2805d | 0d |  | 0.1 |
| 69 | 1.2.3.2 | Управління ціною передбачуваних послуг |  | 10d | 2015-05-29 | 2015-06-11 | 68 | 2805d | 0d |  | 0.15 |
| 70 | 1.2.3.3 | Управління збутом |  | 20d | 2015-06-12 | 2015-07-09 | 69 | 2805d |  |  | 0.5 |
| 71 | 1.2.3.4 | Управління цільовою аудиторією проекту |  | 15d | 2015-05-29 | 2015-06-18 | 68 | 2820d |  |  | 0.7 |
| 72 | 1.2.3.5 | Управління зовнішнім оточенням проекту |  | 15d | 2015-05-29 | 2015-06-18 | 68 | 2820d |  |  | 0.95 |
| 73 | 1.3 | **Фаза створення базової інфраструктури** |  | 2240d | 2015-05-08 | 2023-12-07 | 33, 38 | 0d |  |  | 1,055.73 |
| 74 | 1.3.1 | **Інженерна підготовка території** |  | 780d | 2015-05-08 | 2018-05-03 | 33, 38 | 0d |  |  | 189.73 |
| 75 | 1.3.1.1 | **Гідротехнічні заходи** |  | 450d | 2015-05-08 | 2017-01-26 | 33, 38 | 0d |  |  | 90.53 |
| 76 | 1.3.1.1.1 | **Утворення території під капітальну забудову** |  | 330d | 2015-05-08 | 2016-08-11 | 33, 38 | 0d |  |  | 78.8 |
| 77 | 1.3.1.1.1.1 | Площинна підсипка в оздоровчо-рекреаційній зоні (І) |  | 150d | 2015-05-08 | 2015-12-03 | 33, 38 | 0d |  | start no earlier than 2013-07-16 | 63 |
| 78 | 1.3.1.1.1.2 | Площинна підсипка в оздоровчій зоні (ІІ) |  | 120d | 2015-05-08 | 2015-10-22 | 33, 38 | 30d | 0d | start no earlier than 2013-07-16 | 12.6 |
| 79 | 1.3.1.1.1.3 | Площинна підсипка в парково-громадській зоні (ІІІ) |  | 90d | 2015-05-08 | 2015-09-10 | 33, 38 | 240d | 0d | start no earlier than 2013-07-16 | 3.2 |
| 80 | 1.3.1.1.1.4 | Відстій території в оздоровчо-рекреаційній зоні (І) |  | 180d | 2015-12-04 | 2016-08-11 | 77 | 0d |  | start no earlier than 2014-02-11 |  |
| 81 | 1.3.1.1.1.5 | Відстій території в оздоровчій зоні (ІІ) |  | 180d | 2015-10-23 | 2016-06-30 | 78 | 30d |  | start no earlier than 2013-12-31 |  |
| 82 | 1.3.1.1.1.6 | Відстій території в парково-громадській зоні (ІІІ) |  | 120d | 2015-09-11 | 2016-02-25 | 79 | 240d | 120d | start no earlier than 2013-11-19 |  |
| 83 | 1.3.1.1.1.7 | Територію під капітальну забудову підготовлено | milestone | 0d | 2016-08-11 | 2016-08-11 | 80, 81, 82 | 120d |  | start no earlier than 2014-10-21 |  |
| 84 | 1.3.1.1.2 | Набережна |  | 120d | 2016-08-12 | 2017-01-26 | 80, 81 | 0d |  | start no earlier than 2014-10-21 | 10.75 |
| 85 | 1.3.1.1.3 | Благоустрій пляжів |  | 100d | 2016-08-12 | 2016-12-29 | 80, 81 | 20d |  | start no earlier than 2014-10-21 | 0.98 |
| 86 | 1.3.1.1.4 | Гідротехнічні заходи виконано | milestone | 0d | 2017-01-26 | 2017-01-26 | 83, 84, 85 | 0d |  | start no earlier than 2015-04-07 |  |
| 87 | 1.3.1.2 | **Водопостачання** |  | 330d | 2017-01-27 | 2018-05-03 |  | 0d |  |  | 25.96 |
| 88 | 1.3.1.2.1 | Прокладання вуличної водопровідної мережі |  | 330d | 2017-01-27 | 2018-05-03 | 86 | 0d |  |  | 7.33 |
| 89 | 1.3.1.2.2 | Прокладання внутрішньоділянкової водопровідної мережі |  | 180d | 2017-01-27 | 2017-10-05 | 86 | 150d |  | start no earlier than 2015-04-07 | 7.5 |
| 90 | 1.3.1.2.3 | Будівництво ділянок водопровідних споруд |  | 180d | 2017-01-27 | 2017-10-05 | 86 | 150d |  | start no earlier than 2015-04-07 | 11.13 |
| 91 | 1.3.1.2.4 | Систему водопостачання підготовлено | milestone | 0d | 2018-05-03 | 2018-05-03 | 88, 89, 90 | 0d |  | start no earlier than 2016-08-12 |  |

Notes:
- 67: Витрати на просування проекту
- 68: Витрати на просування проекту
- 69: Витрати на просування проекту
- 70: Витрати на просування проекту
- 71: Витрати на просування проекту
- 72: Витрати на просування проекту
- 73: Бюджетні капітальні інвестиції
- 74: Бюджетні капітальні інвестиції
- 75: Бюджетні капітальні інвестиції
- 76: Бюджетні капітальні інвестиції
- 77: Бюджетні капітальні інвестиції
- 78: Бюджетні капітальні інвестиції
- 79: Бюджетні капітальні інвестиції
- 84: Бюджетні капітальні інвестиції
- 85: Бюджетні капітальні інвестиції
- 87: Бюджетні капітальні інвестиції
- 88: Бюджетні капітальні інвестиції
- 89: Бюджетні капітальні інвестиції
- 90: Бюджетні капітальні інвестиції

| ID | WBS | Task | Type | Duration | Start | Finish | Predecessors | Total slack | Free slack | Constraint | Cost |
| --- | --- | --- | --- | --- | --- | --- | --- | --- | --- | --- | --- |
| 92 | 1.3.1.3 | **Каналізація** |  | 240d | 2017-01-27 | 2017-12-28 | 86 | 90d |  |  | 73.24 |
| 93 | 1.3.1.3.1 | Прокладання вуличної самопливної каналізаційної мережі |  | 210d | 2017-01-27 | 2017-11-16 | 86 | 120d | 30d | start no earlier than 2015-04-07 | 2.38 |
| 94 | 1.3.1.3.2 | Прокладання внутрішньоділянкової каналізаційної мережі |  | 240d | 2017-01-27 | 2017-12-28 | 86 | 90d | 0d | start no earlier than 2015-04-07 | 7.65 |
| 95 | 1.3.1.3.3 | Прокладання напірної каналізаційної мережі |  | 90d | 2017-01-27 | 2017-06-01 | 86 | 240d | 150d | start no earlier than 2015-04-07 | 2.31 |
| 96 | 1.3.1.3.4 | Будівництво каналізаційних насосних станцій |  | 180d | 2017-01-27 | 2017-10-05 | 86 | 150d | 60d | start no earlier than 2015-04-07 | 0.8 |
| 97 | 1.3.1.3.5 | Будівництво каналізаційних очисних споруд |  | 180d | 2017-01-27 | 2017-10-05 | 86 | 150d | 60d | start no earlier than 2015-04-07 | 4 |
| 98 | 1.3.1.3.6 | Вертикальне планування та дощова каналізація |  | 120d | 2017-01-27 | 2017-07-13 | 86 | 210d | 120d |  | 56.1 |
| 99 | 1.3.1.3.7 | Каналізаційну мережу підготовлено | milestone | 0d | 2017-12-28 | 2017-12-28 | 93, 94, 95, 96, 97, 98 | 90d |  | start no earlier than 2016-03-08 |  |
| 100 | 1.3.2 | **Створення ключових обєктів базової інфраструктури** |  | 1460d | 2018-05-04 | 2023-12-07 | 91, 99 | 610d |  |  | 866 |
| 101 | 1.3.2.1 | **Транспорт** |  | 730d | 2018-05-04 | 2021-02-18 | 91, 99 | 610d |  |  | 766 |
| 102 | 1.3.2.1.1 | Будівництво територіальної автомобільної дороги державного значення |  | 365d | 2018-05-04 | 2019-09-26 | 91, 99 | 610d | 0d | start no earlier than 2016-08-12 | 450 |
| 103 | 1.3.2.1.2 | Будівництво мережі житлових вулиць |  | 365d | 2018-05-04 | 2019-09-26 | 91, 99 | 610d | 0d | start no earlier than 2016-08-12 | 210 |
| 104 | 1.3.2.1.3 | Будівництво причалу для приймання суден |  | 365d | 2019-09-27 | 2021-02-18 | 102, 103 | 610d | 0d | start no earlier than 2018-01-05 | 20 |
| 105 | 1.3.2.1.4 | Будівництво перехоплюючої автостоянки |  | 180d | 2019-09-27 | 2020-06-04 | 102 | 795d | 185d | start no earlier than 2018-01-05 | 80 |
| 106 | 1.3.2.1.5 | Будівництво автостоянок біля громадських споруд та житлових будинків |  | 60d | 2019-09-27 | 2019-12-19 | 102, 103 | 915d | 305d |  | 6 |
| 107 | 1.3.2.1.6 | Транспортну мережу підготовлено | milestone | 0d | 2021-02-18 | 2021-02-18 | 104, 105, 106 | 610d | 0d | start no earlier than 2019-05-31 |  |
| 108 | 1.3.2.2 | **Енергопостачання** |  | 730d | 2021-02-19 | 2023-12-07 | 107 | 610d |  |  | 100 |
| 109 | 1.3.2.2.1 | Будівництво обєктів електроенергетики |  | 730d | 2021-02-19 | 2023-12-07 | 107 | 610d | 0d | start no earlier than 2019-05-31 | 100 |
| 110 | 1.3.2.2.2 | Мережу енергопостачання підготовлено | milestone | 0d | 2023-12-07 | 2023-12-07 | 109 | 610d |  | start no earlier than 2022-03-18 |  |
| 111 | 1.4 | **Фаза реалізації локальних інвестиційних проектів** |  | 2070d | 2018-05-04 | 2026-04-09 | 74 | 0d |  |  | 6,703.79 |
| 112 | 1.4.1 | **Будівництво обєктів оздоровчої зони (ІІ)** |  | 1055d | 2018-05-04 | 2022-05-19 | 74 | 715d |  |  | 920.99 |
| 113 | 1.4.1.1 | Спальні корпуси |  | 370d | 2018-05-04 | 2019-10-03 | 74 | 765d | 0d | start no earlier than 2016-08-12 | 96.6 |
| 114 | 1.4.1.2 | Пішохідні галереї |  | 145d | 2019-12-13 | 2020-07-02 | 113, 116 | 840d | 125d | start no earlier than 2018-03-23 | 57.35 |
| 115 | 1.4.1.3 | Зимовий сад |  | 110d | 2020-12-25 | 2021-05-27 | 114, 117, 118 | 970d | 255d | start no earlier than 2019-04-05 | 16.4 |
| 116 | 1.4.1.4 | Бальнеологічний корпус |  | 420d | 2018-05-04 | 2019-12-12 | 74 | 715d | 0d | start no earlier than 2016-08-12 | 54.29 |
| 117 | 1.4.1.5 | Піраміди |  | 120d | 2019-12-13 | 2020-05-28 | 113, 116 | 865d | 150d | start no earlier than 2018-03-23 | 61.86 |
| 118 | 1.4.1.6 | Науково-практичний центр з коридорами |  | 270d | 2019-12-13 | 2020-12-24 | 113, 116 | 715d | 0d | start no earlier than 2018-03-23 | 47.01 |
| 119 | 1.4.1.7 | Комплекс закритих басейнів для водних реабілітаційних процедур |  | 365d | 2020-12-25 | 2022-05-19 | 114, 117, 118 | 715d | 0d | start no earlier than 2019-04-05 | 38.3 |
| 120 | 1.4.1.8 | Прибережні кафе |  | 150d | 2019-12-13 | 2020-07-09 | 113, 116 | 1200d | 485d | start no earlier than 2018-03-23 | 4.8 |
| 121 | 1.4.1.9 | Котельня і пожежна насосна станція |  | 90d | 2018-05-04 | 2018-09-06 | 74 | 1680d | 965d | start no earlier than 2016-08-12 | 3.34 |
| 122 | 1.4.1.10 | Спорудження КСЕСТ в оздоровчій зоні (ІІ) |  | 180d | 2018-05-04 | 2019-01-10 | 74 | 1590d | 875d | start no earlier than 2016-08-12 | 161.8 |
| 123 | 1.4.1.11 | Житлова забудова |  | 720d | 2018-05-04 | 2021-02-04 | 74 | 1050d | 335d |  | 379.24 |
| 124 | 1.4.1.12 | Обєкти оздоровчої інфраструктури підготовлено | milestone | 0d | 2022-05-19 | 2022-05-19 | 115, 119, 120, 121, 122, 123 | 715d | 0d | start no earlier than 2020-08-28 |  |

Notes:
- 92: Бюджетні капітальні інвестиції
- 93: Бюджетні капітальні інвестиції
- 94: Бюджетні капітальні інвестиції
- 95: Бюджетні капітальні інвестиції
- 96: Бюджетні капітальні інвестиції
- 97: Бюджетні капітальні інвестиції
- 98: Бюджетні капітальні інвестиції
- 100: Бюджетні капітальні інвестиції
- 101: Бюджетні капітальні інвестиції
- 102: Бюджетні капітальні інвестиції
- 103: Бюджетні капітальні інвестиції
- 104: Бюджетні капітальні інвестиції
- 105: Бюджетні капітальні інвестиції
- 106: Бюджетні капітальні інвестиції
- 108: Бюджетні капітальні інвестиції
- 109: Бюджетні капітальні інвестиції
- 111: Бюджетні капітальні інвестиції
- 112: Бюджетні капітальні інвестиції
- 113: Бюджетні капітальні інвестиції
- 114: Бюджетні капітальні інвестиції
- 115: Бюджетні капітальні інвестиції
- 116: Бюджетні капітальні інвестиції
- 117: Бюджетні капітальні інвестиції
- 118: Бюджетні капітальні інвестиції
- 119: Бюджетні капітальні інвестиції
- 120: Бюджетні капітальні інвестиції
- 121: Бюджетні капітальні інвестиції
- 122: Бюджетні капітальні інвестиції
- 123: Бюджетні капітальні інвестиції

| ID | WBS | Task | Type | Duration | Start | Finish | Predecessors | Total slack | Free slack | Constraint | Cost |
| --- | --- | --- | --- | --- | --- | --- | --- | --- | --- | --- | --- |
| 125 | 1.4.2 | **Будівництво обєктів оздоровчо-рекреаційної зони (І)** |  | 1140d | 2020-04-03 | 2024-08-15 | 74FS+500d | 0d |  |  | 5,557.35 |
| 126 | 1.4.2.1 | Санаторії для батьків з дітьми та дитячі санаторії | manual | 770d | 2020-04-03 | 2023-03-16 | 74FS+500d |  |  | start no earlier than 2018-07-13 | 1,958.4 |
| 127 | 1.4.2.2 | Розважальний центр |  | 210d | 2023-03-17 | 2024-01-04 | 126, 128, 129 | 590d | 160d | start no earlier than 2021-06-25 | 130 |
| 128 | 1.4.2.3 | Курортні готелі |  | 560d | 2020-04-03 | 2022-05-26 | 74FS+500d | 640d | 210d | start no earlier than 2018-07-13 | 691.2 |
| 129 | 1.4.2.4 | Пансіонати |  | 720d | 2020-04-03 | 2023-01-05 | 74FS+500d | 640d | 50d | start no earlier than 2018-07-13 | 547.2 |
| 130 | 1.4.2.5 | Міні-пансіонати |  | 280d | 2020-04-03 | 2021-04-29 | 74FS+500d | 1170d | 490d | start no earlier than 2018-07-13 | 460.8 |
| 131 | 1.4.2.6 | Молодіжний табір |  | 155d | 2023-03-17 | 2023-10-19 | 126 | 645d | 215d | start no earlier than 2021-06-25 | 80.64 |
| 132 | 1.4.2.7 | Етнокомплекси |  | 370d | 2023-03-17 | 2024-08-15 | 126, 128 | 430d | 0d |  | 345.6 |
| 133 | 1.4.2.8 | Басейни |  | 120d | 2023-03-17 | 2023-08-31 | 126, 128, 129, 130 | 680d | 250d |  | 117 |
| 134 | 1.4.2.9 | Спорудження КСЕСТ в оздоровчо-рекреаційній зоні (І) |  | 365d | 2020-04-03 | 2021-08-26 | 74FS+500d | 1205d | 775d | start no earlier than 2018-07-13 | 689 |
| 135 | 1.4.2.10 | Житлова забудова |  | 720d | 2020-04-03 | 2023-01-05 | 74FS+500d | 850d | 420d |  | 369.51 |
| 136 | 1.4.2.11 | Коледж |  | 212d | 2023-03-17 | 2024-01-08 | 126 | 588d |  |  | 168 |
| 137 | 1.4.2.12 | Обєкти туристичної інфраструктури підготовлено | milestone | 0d | 2024-08-15 | 2024-08-15 | 126, 127, 128, 129, 130, 131, 132, 133, 134, 135 | 430d |  | start no earlier than 2022-11-25 |  |
| 138 | 1.4.3 | **Будівництво обєктів парково-громадської зони (ІІІ)** |  | 800d | 2023-03-17 | 2026-04-09 | 126 | 0d |  |  | 188.25 |
| 139 | 1.4.3.1 | Аквапарк |  | 330d | 2023-03-17 | 2024-06-20 | 126 | 470d |  | start no earlier than 2021-06-25 | 31.65 |
| 140 | 1.4.3.2 | Універсальний розважальний центр |  | 270d | 2024-03-29 | 2025-04-10 | 141 | 260d |  | start no earlier than 2022-07-08 | 10.4 |
| 141 | 1.4.3.3 | Спортивний центр |  | 270d | 2023-03-17 | 2024-03-28 | 126 | 0d |  | start no earlier than 2021-06-25 | 10.4 |
| 142 | 1.4.3.4 | Торгово-виставковий центр |  | 350d | 2024-03-29 | 2025-07-31 | 141 | 0d |  | start no earlier than 2022-07-08 | 41.6 |
| 143 | 1.4.3.5 | Тематичні парки |  | 180d | 2025-08-01 | 2026-04-09 | 142 | 0d |  | start no earlier than 2023-11-10 | 45 |
| 144 | 1.4.3.6 | Спорудження КСЕСТ в парково-громадської зоні (ІІІ) |  | 180d | 2023-03-17 | 2023-11-23 | 126 | 620d |  |  | 49.2 |
| 145 | 1.4.3.7 | Обєкти парково-громадської зони підготовлено | milestone | 0d | 2026-04-09 | 2026-04-09 | 141, 142, 143, 144, 139, 140 | 0d |  | start no earlier than 2024-07-19 |  |
| 146 | 1.4.4 | **Санітарне очищення** |  | 1700d | 2019-10-04 | 2026-04-09 | 113 | 0d |  |  | 5.2 |
| 147 | 1.4.4.1 | Придбання сміттєвозів |  | 30d | 2019-10-04 | 2019-11-14 | 113 | 1625d | 0d |  | 2.1 |
| 148 | 1.4.4.2 | Придбання прибіральних машин та механізмів |  | 30d | 2019-11-15 | 2019-12-26 | 147 | 1625d |  |  | 2.8 |
| 149 | 1.4.4.3 | Розробка схеми санітарного очищення |  | 15d | 2026-03-20 | 2026-04-09 | 148, 145FF | 0d |  |  | 0.3 |

Notes:
- 126: Внебюджетні інвестиції
- 127: Внебюджетні інвестиції
- 128: Внебюджетні інвестиції
- 129: Внебюджетні інвестиції
- 130: Внебюджетні інвестиції
- 131: Внебюджетні інвестиції
- 132: Внебюджетні інвестиції
- 133: Внебюджетні інвестиції
- 134: Бюджетні капітальні інвестиції
- 135: Бюджетні капітальні інвестиції
- 136: Внебюджетні інвестиції
- 139: Внебюджетні інвестиції
- 140: Внебюджетні інвестиції
- 141: Внебюджетні інвестиції
- 142: Внебюджетні інвестиції
- 143: Внебюджетні інвестиції
- 144: Бюджетні капітальні інвестиції
- 146: Бюджетні капітальні інвестиції
- 147: Бюджетні капітальні інвестиції
- 148: Бюджетні капітальні інвестиції
- 149: Бюджетні капітальні інвестиції

| ID | WBS | Task | Type | Duration | Start | Finish | Predecessors | Total slack | Free slack | Cost |
| --- | --- | --- | --- | --- | --- | --- | --- | --- | --- | --- |
| 150 | 1.4.5 | **Благоустрій, озеленення** |  | 1015d | 2022-05-20 | 2026-04-09 | 124 | 0d |  | 32 |
| 151 | 1.4.5.1 | Озеленення території |  | 120d | 2022-05-20 | 2022-11-03 | 124 | 715d | 0d | 17.2 |
| 152 | 1.4.5.2 | Влаштування газонів |  | 90d | 2022-11-04 | 2023-03-09 | 151 | 715d |  | 6.6 |
| 153 | 1.4.5.3 | Влаштування пішохідних доріжок |  | 90d | 2025-12-05 | 2026-04-09 | 152, 145FF | 0d |  | 8.2 |
| 154 | 1.5 | Реалізацію локальних інвестиційних проектів завершено | milestone | 0d | 2026-04-09 | 2026-04-09 | 124, 137, 145, 149, 153 | 0d |  |  |

Notes:
- 150: Бюджетні капітальні інвестиції
- 151: Бюджетні капітальні інвестиції
- 152: Бюджетні капітальні інвестиції
- 153: Бюджетні капітальні інвестиції
